# CEB Press Workshop_leveled

Schedule from MS Project, 2014-07-09 to 2014-07-10.
Open Source ecology

## Calendars

- Padrão: Mon-Fri 09:00-12:00, 13:00-18:00; Sat-Sun off.

## Resources

| Resource |
| --- |
| Marcin |
| Aidan |
| Danny |
| Brenna |
| Víctor |
| Guillaume |
| Clair |
| Emily |
| Stephen |
| Edo |
| Moriah |
| Michael |
| Devin |
| Curtis |
| Yann |

## Schedule

| ID | WBS | Task | Duration | Start | Finish | Predecessors | Total slack | Free slack | Resources | Work |
| --- | --- | --- | --- | --- | --- | --- | --- | --- | --- | --- |
| 1 | 1 | **CEB Press Workshop** | 1.36d? | 2014-07-09 09:00 | 2014-07-10 11:54 |  | 0d |  |  | 57.54h |
| 2 | 1.1 | **Phase 1: Training** | 0.06d | 2014-07-09 09:00 | 2014-07-09 09:30 |  | 0d |  |  | 3.5h |
| 3 | 1.1.1 | Open Lecture | 0.5h | 2014-07-09 09:00 | 2014-07-09 09:30 |  | 0d |  | Aidan; Devin; Guillaume; Stephen; Emily; Brenna; Marcin | 3.5h |
| 4 | 1.2 | **Phase 2: Pre-Assembly** | 0.63d? | 2014-07-09 09:30 | 2014-07-09 15:34 |  | 0d |  |  | 11.5h |
| 5 | 1.2.1 | Inventory | 1h? | 2014-07-09 09:30 | 2014-07-09 10:30 | 3 | 0d |  | Aidan; Devin; Guillaume; Stephen; Emily; Brenna | 6h |
| 6 | 1.2.2 | **Pre-prepared pieces** | 0.51d? | 2014-07-09 10:30 | 2014-07-09 15:34 |  | 0.11d |  |  | 5.5h |
| 7 | 1.2.2.1 | Cutting 20 short and 8 long square tubing | 0.83h | 2014-07-09 11:10 | 2014-07-09 12:00 | 5 | 0.15d | 0d | Aidan; Brenna | 1h |
| 8 | 1.2.2.2 | **Shearing** | 0.32d | 2014-07-09 13:00 | 2014-07-09 15:34 |  | 0.01d |  |  | 0.91h |
| 9 | 1.2.2.2.1 | 32 grate members | 0.5h | 2014-07-09 14:49 | 2014-07-09 15:19 | 5 | 0.5d | 0.02d | Aidan | 0.5h |
| 10 | 1.2.2.2.2 | Shaker hammer | 0.08h | 2014-07-09 15:29 | 2014-07-09 15:34 | 5 | 0.3d | 0d | Aidan | 0.08h |
| 11 | 1.2.2.2.3 | Hopper hinges | 0.33h | 2014-07-09 13:00 | 2014-07-09 13:19 | 5 | 0.01d | 0d | Aidan | 0.33h |
| 12 | 1.2.2.3 | Punching the transfer marking hopper hinge holes and the hopper hinge holes | 0.12d | 2014-07-09 10:30 | 2014-07-09 11:30 | 5 | 0.11d | 0.1d | Aidan | 1h |
| 13 | 1.2.2.4 | **Mag drilling** | 0.27d? | 2014-07-09 10:30 | 2014-07-09 13:39 |  | 0.15d |  |  | 0.75h |
| 14 | 1.2.2.4.1 | Drill 20 short square tubing | 0.33h? | 2014-07-09 13:19 | 2014-07-09 13:39 | 7, 5 | 0.15d | 0d | Aidan | 0.33h |
| 15 | 1.2.2.4.2 | Drill 2 holes in the press foot for the main cylinder | 0.42h | 2014-07-09 10:30 | 2014-07-09 10:55 | 5 | 0.32d | 0d | Marcin | 0.42h |
| 16 | 1.2.2.5 | **Welding** | 0.5d? | 2014-07-09 10:30 | 2014-07-09 15:29 |  | 0.16d |  |  | 1.83h |
| 17 | 1.2.2.5.1 | Weld nuts on 4 short square tubing for feet | 0.02d | 2014-07-09 13:59 | 2014-07-09 14:09 | 7, 5 | 0.37d | 0d | Aidan | 0.17h |
| 18 | 1.2.2.5.2 | Weld nuts on 8 short square tubing for secondary arms | 0.04d | 2014-07-09 13:00 | 2014-07-09 13:19 | 7, 5 | 0.16d | 0d | Emily | 0.33h |
| 19 | 1.2.2.5.3 | Weld nuts on 8 short square tubing for hopper support | 0.04d | 2014-07-09 13:39 | 2014-07-09 13:59 | 7, 5 | 0.29d | 0d | Aidan | 0.33h |
| 20 | 1.2.2.5.4 | Weld 16 nuts on the hopper exterior and 4 nuts on the hopper interior | 0.67h | 2014-07-09 10:30 | 2014-07-09 11:10 | 5 | 0.16d | 0.14d | Brenna | 0.67h |
| 21 | 1.2.2.5.5 | Weld 4 nuts on the grate interior | 0.02d? | 2014-07-09 15:19 | 2014-07-09 15:29 | 5 | 0.48d | 0d | Aidan | 0.17h |
| 22 | 1.2.2.5.6 | Weld 4 nuts on the linear guide brackets | 0.02d? | 2014-07-09 14:39 | 2014-07-09 14:49 | 5 | 0.37d | 0d | Aidan | 0.17h |
| 23 | 1.3 | **Phase 3: Modules Assembly** | 1.1d? | 2014-07-09 10:30 | 2014-07-10 11:19 |  | 0d |  |  | 36.09h |
| 24 | 1.3.1 | Frame | 6h | 2014-07-09 10:30 | 2014-07-09 17:30 | 5 | 0d |  | Stephen | 6h |

Notes:
- 3: Intro to OSE and CEB Press
- 5: When the pieces will arrive?
- 14: Make sure you have coolant (diesel) or even water]

| ID | WBS | Task | Type | Duration | Start | Finish | Predecessors | Total slack | Free slack | Resources | Work |
| --- | --- | --- | --- | --- | --- | --- | --- | --- | --- | --- | --- |
| 25 | 1.3.2 | **Drawer** |  | 0.58d? | 2014-07-09 10:30 | 2014-07-09 16:10 |  | 0.17d |  |  | 6.17h |
| 26 | 1.3.2.1 | Assemble Drawer |  | 4.5h? | 2014-07-09 10:30 | 2014-07-09 16:00 | 5 | 0.17d | 0d | Devin | 4.5h |
| 27 | 1.3.2.2 | Assemble Drawer Guides Brackets |  | 1.5h | 2014-07-09 10:30 | 2014-07-09 12:00 | 5 | 0.54d | 0.38d | Guillaume | 1.5h |
| 28 | 1.3.2.3 | Mounting brackets on the drawer |  | 0.17h? | 2014-07-09 16:00 | 2014-07-09 16:10 | 26, 27 | 0.17d |  | Devin | 0.17h |
| 29 | 1.3.3 | Linear Guides |  | 1h | 2014-07-09 14:49 | 2014-07-09 15:49 | 5, 22 | 0.37d | 0.28d | Brenna | 1h |
| 30 | 1.3.4 | Main Cylinder |  | 3h | 2014-07-09 10:55 | 2014-07-09 14:55 | 15, 5 | 0.32d |  | Marcin | 3h |
| 31 | 1.3.5 | Primary Arms |  | 2.75h | 2014-07-09 13:39 | 2014-07-09 16:24 | 14, 5 | 0.15d | 0d | Guillaume | 2.75h |
| 32 | 1.3.6 | Secondary Arms |  | 0.38d? | 2014-07-09 13:19 | 2014-07-09 16:19 | 5, 7, 18 | 0.16d | 0.01d | Emily | 3h |
| 33 | 1.3.7 | Hopper |  | 0.75d? | 2014-07-09 13:19 | 2014-07-10 11:19 | 5, 11, 12, 20 | 0.01d | 0d | Brenna | 6h |
| 34 | 1.3.8 | Hopper Support |  | 0.3d? | 2014-07-09 15:35 | 2014-07-10 09:04 | 5, 7, 19 | 0.29d | 0.28d | Aidan; Marcin | 3h |
| 35 | 1.3.9 | Grate |  | 0.12d? | 2014-07-09 15:34 | 2014-07-09 16:34 | 9, 5, 21 | 0.48d | 0.47d | Aidan | 1h |
| 36 | 1.3.10 | Legs and Feet |  | 0.06d? | 2014-07-09 14:09 | 2014-07-09 14:39 | 7, 5, 17 | 0.37d | 0.22d | Aidan | 0.5h |
| 37 | 1.3.11 | Hopper Shaker |  | 0.09d? | 2014-07-09 17:19 | 2014-07-10 09:04 | 10, 5 | 0.29d | 0.28d | Emily | 0.75h |
| 38 | 1.3.12 | Secondary Cylinder |  | 0.42h | 2014-07-09 13:00 | 2014-07-09 13:25 | 5 | 0.58d |  | Guillaume | 0.42h |
| 39 | 1.3.13 | Solenoid |  | 0.31d? | 2014-07-09 10:30 | 2014-07-09 17:19 | 5 | 0.15d |  | Emily | 2.5h |
| 40 | 1.3.14 | Controller | milestone | 0d? | 2014-07-09 10:30 | 2014-07-09 10:30 | 5 | 0.92d |  | Marcin |  |
| 41 | 1.4 | **Phase 4: Modules Integrations** |  | 0.52d? | 2014-07-09 16:24 | 2014-07-10 11:34 |  | 0.01d |  |  | 4.46h |
| 42 | 1.4.1 | Step 1. Core assembled |  | 0.03d? | 2014-07-09 17:30 | 2014-07-09 17:45 | 24, 30, 28 | 0d |  | Devin; Stephen | 0.5h |
| 43 | 1.4.2 | Step 2. Lower Structure assembled |  | 0.02d? | 2014-07-09 16:24 | 2014-07-09 16:32 | 31, 32, 36 | 0.15d |  | Guillaume; Marcin | 0.25h |
| 44 | 1.4.3 | Step 3. Core integrated in the Lower Structure |  | 0.04d? | 2014-07-09 17:45 | 2014-07-10 09:05 | 43, 42 | 0d |  | Devin; Stephen | 0.67h |
| 45 | 1.4.4 | Step 4. Secondary Cylinder integrated |  | 0.05d? | 2014-07-10 09:05 | 2014-07-10 09:30 | 38, 44 | 0d |  | Marcin | 0.42h |
| 46 | 1.4.5 | Step 5. Linear Guides integrated |  | 0.02d? | 2014-07-10 09:05 | 2014-07-10 09:15 | 44, 29 | 0.09d |  | Devin; Stephen | 0.33h |
| 47 | 1.4.6 | Step 6. Solenoid integrated |  | 0.04d? | 2014-07-10 09:30 | 2014-07-10 09:50 | 45, 39 | 0d |  | Marcin | 0.33h |
| 48 | 1.4.7 | Step 7. Controller integrated |  | 0.02d? | 2014-07-10 09:50 | 2014-07-10 09:57 | 47, 40 | 0d |  | Marcin | 0.12h |
| 49 | 1.4.8 | Step 8. Tables integrated |  | 0.01d? | 2014-07-10 09:30 | 2014-07-10 09:35 | 45 | 0.05d |  | Devin; Stephen | 0.17h |
| 50 | 1.4.9 | Step 9. Drewar Guards integrated |  | 0.01d? | 2014-07-10 10:12 | 2014-07-10 10:17 | 55 | 0.14d | 0.13d | Devin; Stephen | 0.17h |
| 51 | 1.4.10 | Step 10. Hopper integrated |  | 0.03d? | 2014-07-10 11:19 | 2014-07-10 11:34 | 50, 33, 34, 35, 37 | 0.01d |  | Devin; Stephen; Emily; Aidan; Guillaume; Marcin | 1.5h |

| ID | WBS | Task | Type | Duration | Start | Finish | Predecessors | Total slack | Resources | Work |
| --- | --- | --- | --- | --- | --- | --- | --- | --- | --- | --- |
| 52 | 1.5 | **Phase 5: Testing** |  | 0.37d? | 2014-07-09 17:57 | 2014-07-10 11:54 |  | 0d |  | 2h |
| 53 | 1.5.1 | Power source ready | milestone | 0d | 2014-07-09 17:57 | 2014-07-09 17:57 | 55SS-1h | 0.37d | Marcin |  |
| 54 | 1.5.2 | Soil mixed for the Manual Pilot Batch |  | 0.06d? | 2014-07-09 17:57 | 2014-07-10 09:27 | 55SS-1h | 0.31d | Guillaume | 0.5h |
| 55 | 1.5.3 | Manual pilot batch |  | 0.25h | 2014-07-10 09:57 | 2014-07-10 10:12 | 48, 49, 46 | 0d | Marcin | 0.25h |
| 56 | 1.5.4 | Soil mixed for the Automatic Pilot Batch |  | 0.08d? | 2014-07-10 10:12 | 2014-07-10 11:39 | 55 | 0d | Guillaume; Emily; Brenna | 1h |
| 57 | 1.5.5 | Automatic pilot batch |  | 0.25h | 2014-07-10 11:39 | 2014-07-10 11:54 | 51, 56 | 0d | Marcin | 0.25h |
